# Productieschema ontwerpproces eenvoudig utiliteitsbouw

Schedule from MS Project, 2002-12-30 to 2003-06-13.
BAM Nelissen Van Egteren

## Calendars

- Standaard: Mon-Fri 08:30-12:30, 13:00-17:00; Sat-Sun off.

## Schedule

| ID | WBS | Task | Type | Duration | Start | Finish | Predecessors | Total slack | Free slack |
| --- | --- | --- | --- | --- | --- | --- | --- | --- | --- |
| 1 | 1 | **INITIATIEF** |  | 30d | 2002-12-30 | 2003-02-07 |  | 90d |  |
| 2 | 1.1 | discussie over huisvestingsproblemen |  | 2w | 2002-12-30 | 2003-01-10 |  | 90d | 0d |
| 3 | 1.2 | klachten over bestaande huisvesting |  | 2w | 2003-01-13 | 2003-01-24 | 2 | 90d | 0d |
| 4 | 1.3 | voordelen van nieuwe huisvesting |  | 2w | 2003-01-27 | 2003-02-07 | 3 | 90d | 0d |
| 5 | 1.4 | besluit: haalbaarheid onderzoeken | milestone | 0w | 2003-02-07 | 2003-02-07 | 4 | 90d |  |
| 7 | 2 | **HAALBAARHEID** |  | 45d | 2002-12-30 | 2003-02-28 |  | 75d |  |
| 8 | 2.1 | **organiseren** |  | 10d | 2002-12-30 | 2003-01-10 |  | 75d |  |
| 9 | 2.1.1 | plan van aanpak maken |  | 1w | 2002-12-30 | 2003-01-03 |  | 75d | 0d |
| 10 | 2.1.2 | programma-team bemannen |  | 1w | 2003-01-06 | 2003-01-10 | 9 | 75d | 0d |
| 11 | 2.2 | **programmeren: functioneel** |  | 15d | 2003-01-13 | 2003-01-31 |  | 75d |  |
| 12 | 2.2.1 | concept functionele analyse |  | 1w | 2003-01-13 | 2003-01-17 | 10 | 75d | 0d |
| 13 | 2.2.2 | overleg met betrokkenen |  | 1w | 2003-01-20 | 2003-01-24 | 12 | 95d | 0d |
| 14 | 2.2.3 | document functionele analyse |  | 1w | 2003-01-27 | 2003-01-31 | 13 | 95d |  |
| 15 | 2.3 | **programmeren: ruimtelijk** |  | 15d | 2003-01-20 | 2003-02-07 |  | 85d |  |
| 16 | 2.3.1 | concept ruimtelijke analyse |  | 1w | 2003-01-20 | 2003-01-24 | 12 | 85d | 0d |
| 17 | 2.3.2 | overleg met betrokkenen |  | 1w | 2003-01-27 | 2003-01-31 | 16 | 85d | 0d |
| 18 | 2.3.3 | document ruimtelijke analyse |  | 1w | 2003-02-03 | 2003-02-07 | 17 | 85d | 0d |
| 19 | 2.4 | **programmeren: technisch** |  | 15d | 2003-01-20 | 2003-02-07 |  | 75d |  |
| 20 | 2.4.1 | concept technische analyse |  | 1w | 2003-01-20 | 2003-01-24 | 12 | 75d | 0d |
| 21 | 2.4.2 | overleg met betrokkenen |  | 1w | 2003-01-27 | 2003-01-31 | 20 | 85d | 0d |
| 22 | 2.4.3 | document technische analyse |  | 1w | 2003-02-03 | 2003-02-07 | 21 | 85d | 0d |
| 23 | 2.5 | **programmeren: financieel** |  | 15d | 2003-01-27 | 2003-02-14 |  | 75d |  |
| 24 | 2.5.1 | concept financiele analyse |  | 1w | 2003-01-27 | 2003-01-31 | 20 | 75d | 0d |
| 25 | 2.5.2 | overleg met betrokkene |  | 1w | 2003-02-03 | 2003-02-07 | 24 | 75d | 0d |
| 26 | 2.5.3 | document financiele analyse |  | 1w | 2003-02-10 | 2003-02-14 | 25 | 75d | 0d |

| ID | WBS | Task | Type | Duration | Start | Finish | Predecessors | Total slack | Free slack |
| --- | --- | --- | --- | --- | --- | --- | --- | --- | --- |
| 27 | 2.6 | **beoordelen** |  | 10d | 2003-02-10 | 2003-02-21 |  | 80d |  |
| 28 | 2.6.1 | toets ruimtelijk aan functioneel |  | 1w | 2003-02-10 | 2003-02-14 | 18 | 85d |  |
| 29 | 2.6.2 | toets technisch aan functioneel |  | 1w | 2003-02-10 | 2003-02-14 | 22 | 85d |  |
| 30 | 2.6.3 | toets financieel aan functioneel |  | 1w | 2003-02-17 | 2003-02-21 | 26 | 75d | 0d |
| 31 | 2.7 | **besluiten** |  | 5d | 2003-02-24 | 2003-02-28 |  | 75d |  |
| 32 | 2.7.1 | besluitvorming voorbereiden |  | 1w | 2003-02-24 | 2003-02-28 | 30 | 75d | 0d |
| 33 | 2.7.2 | haalbaarheid goedgekeurd | milestone | 0w | 2003-02-28 | 2003-02-28 | 32 | 75d |  |
| 35 | 3 | **PROJECTDEFINITIE** |  | 65d | 2002-12-30 | 2003-03-28 |  | 55d |  |
| 36 | 3.1 | **organiseren** |  | 5d | 2002-12-30 | 2003-01-03 |  | 115d |  |
| 37 | 3.1.1 | plan van aanpak opstellen |  | 1w | 2002-12-30 | 2003-01-03 |  | 115d |  |
| 38 | 3.1.2 | programmateam bemannen |  | 1w | 2002-12-30 | 2003-01-03 |  | 170d |  |
| 39 | 3.2 | **programmeren: functioneel** |  | 20d | 2002-12-30 | 2003-01-24 |  | 55d |  |
| 40 | 3.2.1 | concept funct. basisprogramma |  | 2w | 2002-12-30 | 2003-01-10 |  | 55d | 0d |
| 41 | 3.2.2 | overleg met betrokkenen |  | 1w | 2003-01-13 | 2003-01-17 | 40 | 100d | 0d |
| 42 | 3.2.3 | document funct. basisprogramma |  | 1w | 2003-01-20 | 2003-01-24 | 41 | 100d |  |
| 43 | 3.3 | **programmeren: ruimtelijk** |  | 20d | 2003-01-13 | 2003-02-07 |  | 55d |  |
| 44 | 3.3.1 | concept ruimtelijk basisprogramma |  | 2w | 2003-01-13 | 2003-01-24 | 40 | 55d | 0d |
| 45 | 3.3.2 | overleg met betrokkene |  | 1w | 2003-01-27 | 2003-01-31 | 44 | 85d | 0d |
| 46 | 3.3.3 | document ruimtelijk basisprogramma |  | 1w | 2003-02-03 | 2003-02-07 | 45 | 85d | 0d |
| 47 | 3.4 | **programmeren: technisch** |  | 20d | 2003-01-27 | 2003-02-21 |  | 55d |  |
| 48 | 3.4.1 | concept technisch basisprogramma |  | 2w | 2003-01-27 | 2003-02-07 | 44 | 55d | 0d |
| 49 | 3.4.2 | overleg met betrokkenen |  | 1w | 2003-02-10 | 2003-02-14 | 48 | 75d | 0d |
| 50 | 3.4.3 | document technisch basisprogram |  | 1w | 2003-02-17 | 2003-02-21 | 49 | 75d | 0d |
| 51 | 3.5 | **programmeren: financieel** |  | 20d | 2003-02-10 | 2003-03-07 |  | 55d |  |
| 52 | 3.5.1 | concept financieel basisprogramma |  | 2w | 2003-02-10 | 2003-02-21 | 48 | 55d | 0d |
| 53 | 3.5.2 | overleg met betrokkenen |  | 1w | 2003-02-24 | 2003-02-28 | 52 | 55d | 0d |
| 54 | 3.5.3 | document financieel basisprogramma |  | 1w | 2003-03-03 | 2003-03-07 | 53 | 55d | 0d |

| ID | WBS | Task | Type | Duration | Start | Finish | Predecessors | Total slack | Free slack |
| --- | --- | --- | --- | --- | --- | --- | --- | --- | --- |
| 55 | 3.6 | **beoordelen** |  | 25d | 2003-02-10 | 2003-03-14 |  | 65d |  |
| 56 | 3.6.1 | toets ruimtelijk program aan funct. |  | 1w | 2003-02-10 | 2003-02-14 | 46 | 85d |  |
| 57 | 3.6.2 | toets technisch program aan funct. |  | 1w | 2003-02-24 | 2003-02-28 | 50 | 75d |  |
| 58 | 3.6.3 | toets financieel program aan funct. |  | 1w | 2003-03-10 | 2003-03-14 | 54 | 55d | 0d |
| 59 | 3.7 | **besluiten** |  | 10d | 2003-03-17 | 2003-03-28 |  | 55d |  |
| 60 | 3.7.1 | besluitvorming voorbereiden |  | 2w | 2003-03-17 | 2003-03-28 | 58 | 55d | 0d |
| 61 | 3.7.2 | projectdefinitie goedgekeurd | milestone | 0w | 2003-03-28 | 2003-03-28 | 60 | 55d |  |
| 63 | 4 | **STRUCTUUR ONTWERP** |  | 115d | 2002-12-30 | 2003-06-06 |  | 5d |  |
| 64 | 4.1 | opdracht voor structuur ontwerp | milestone | 0w | 2002-12-30 | 2002-12-30 |  | 15d | 0d |
| 65 | 4.2 | **organiseren: plan van aanpak** |  | 25d | 2002-12-30 | 2003-01-31 |  | 95d |  |
| 66 | 4.2.1 | plan van aanpak opstellen |  | 2w | 2002-12-30 | 2003-01-10 | 64 | 145d | 0d |
| 67 | 4.2.2 | overleg over plan van aanpak |  | 1w | 2003-01-13 | 2003-01-17 | 66 | 95d | 0d |
| 68 | 4.2.3 | document plan van aanpak |  | 1w | 2003-01-20 | 2003-01-24 | 67 | 95d | 0d |
| 69 | 4.2.4 | project-organisatie bemannen |  | 1w | 2003-01-27 | 2003-01-31 | 68 | 95d |  |
| 70 | 4.3 | **organiseren: architect** |  | 20d | 2002-12-30 | 2003-01-24 |  | 5d |  |
| 71 | 4.3.1 | selecteren architect |  | 2w | 2002-12-30 | 2003-01-10 | 64 | 15d | 0d |
| 72 | 4.3.2 | overleg met architect over program |  | 1w | 2003-01-13 | 2003-01-17 | 71 | 5d | 0d |
| 73 | 4.3.3 | opstellen ontwerpopdracht |  | 1w | 2003-01-20 | 2003-01-24 | 72 | 5d | 0d |
| 74 | 4.3.4 | tekenen ontwerpopdracht | milestone | 0w | 2003-01-24 | 2003-01-24 | 73 | 5d | 0d |
| 75 | 4.4 | **programmeren** |  | 20d | 2002-12-30 | 2003-01-24 |  | 100d |  |
| 76 | 4.4.1 | funct. basisprogram actualiseren |  | 1w | 2002-12-30 | 2003-01-03 | 64 | 100d | 0d |
| 77 | 4.4.2 | ruimtelijk basisprogram actualiseren |  | 1w | 2003-01-06 | 2003-01-10 | 76SS+1w | 100d | 0d |
| 78 | 4.4.3 | technisch basisprogram actualiseren |  | 1w | 2003-01-13 | 2003-01-17 | 77SS+1w | 155d | 0d |
| 79 | 4.4.4 | financieel basisprogram actualiseren |  | 1w | 2003-01-20 | 2003-01-24 | 78SS+1w | 155d |  |

| ID | WBS | Task | Type | Duration | Start | Finish | Predecessors | Total slack | Free slack |
| --- | --- | --- | --- | --- | --- | --- | --- | --- | --- |
| 80 | 4.5 | **ontwerpen: structuur ontwerp** |  | 55d | 2003-01-27 | 2003-04-11 |  | 5d |  |
| 81 | 4.5.1 | nota ontwerp - uitgangspunten |  | 1w | 2003-01-27 | 2003-01-31 | 74 | 5d | 0d |
| 82 | 4.5.2 | structuur ontwerp variant 1 |  | 3w | 2003-02-03 | 2003-02-21 | 81 | 5d | 0d |
| 83 | 4.5.3 | structuur ontwerp variant 2 |  | 2w | 2003-02-24 | 2003-03-07 | 82SS+3w | 70d |  |
| 84 | 4.5.4 | structuur ontwerp variant 3 |  | 2w | 2003-03-10 | 2003-03-21 | 82SS+5w | 5d | 0d |
| 85 | 4.5.5 | overleg over ontwerp varianten |  | 2w | 2003-03-24 | 2003-04-04 | 84 | 5d | 0d |
| 86 | 4.5.6 | kiezen van ontwerp-variant |  | 1w | 2003-04-07 | 2003-04-11 | 85 | 5d | 0d |
| 87 | 4.6 | **begroten** |  | 20d | 2003-04-14 | 2003-05-09 |  | 5d |  |
| 88 | 4.6.1 | element-cluster begroting concept |  | 2w | 2003-04-14 | 2003-04-25 | 86 | 5d | 0d |
| 89 | 4.6.2 | overleg over begroting |  | 1w | 2003-04-28 | 2003-05-02 | 88 | 5d | 0d |
| 90 | 4.6.3 | element-cluster begroting afronden |  | 1w | 2003-05-05 | 2003-05-09 | 89 | 5d | 0d |
| 91 | 4.7 | **beoordelen** |  | 30d | 2003-04-14 | 2003-05-23 |  | 15d |  |
| 92 | 4.7.1 | toets SO aan functioneel programma |  | 1w | 2003-04-14 | 2003-04-18 | 86 | 30d | 0d |
| 93 | 4.7.2 | toets SO aan ruimtelijk programma |  | 1w | 2003-04-21 | 2003-04-25 | 92 | 30d | 0d |
| 94 | 4.7.3 | toets SO aan technisch programma |  | 1w | 2003-04-28 | 2003-05-02 | 93 | 30d |  |
| 95 | 4.7.4 | toets SO aan financieel programma |  | 1w | 2003-05-12 | 2003-05-16 | 90 | 5d | 0d |
| 96 | 4.7.5 | afwijkingsrapport opstellen |  | 1w | 2003-05-19 | 2003-05-23 | 95 | 5d | 0d |
| 97 | 4.8 | **besluiten** |  | 10d | 2003-05-26 | 2003-06-06 |  | 5d |  |
| 98 | 4.8.1 | besluitvorming voorbereiden |  | 2w | 2003-05-26 | 2003-06-06 | 96 | 5d | 0d |
| 99 | 4.8.2 | structuurontwerp goedgekeurd | milestone | 0w | 2003-06-06 | 2003-06-06 | 98 | 5d |  |
| 101 | 5 | **VOORLOPIG ONTWERP** |  | 105d | 2002-12-30 | 2003-05-23 |  | 15d |  |
| 102 | 5.1 | opdracht voor voorlopig ontwerp | milestone | 0w | 2002-12-30 | 2002-12-30 |  | 15d | 0d |
| 103 | 5.2 | **organiseren: plan van aanpak** |  | 20d | 2002-12-30 | 2003-01-24 |  | 15d |  |
| 104 | 5.2.1 | plan van aanpak opstellen |  | 1w | 2002-12-30 | 2003-01-03 | 102 | 15d | 0d |
| 105 | 5.2.2 | overleg over plan van aanpak |  | 1w | 2003-01-06 | 2003-01-10 | 104 | 15d | 0d |
| 106 | 5.2.3 | document plan van aanpak |  | 1w | 2003-01-13 | 2003-01-17 | 105 | 15d | 0d |
| 107 | 5.2.4 | project-team bemannen |  | 1w | 2003-01-20 | 2003-01-24 | 106 | 15d | 0d |

| ID | WBS | Task | Type | Duration | Start | Finish | Predecessors | Total slack | Free slack |
| --- | --- | --- | --- | --- | --- | --- | --- | --- | --- |
| 108 | 5.3 | **organiseren: adviseurs aantrekken** |  | 20d | 2002-12-30 | 2003-01-24 |  | 100d |  |
| 109 | 5.3.1 | selecteren constructiebureau |  | 2w | 2002-12-30 | 2003-01-10 | 102 | 155d | 0d |
| 110 | 5.3.2 | ontwerp-contract opstellen |  | 1w | 2003-01-13 | 2003-01-17 | 109 | 105d | 0d |
| 111 | 5.3.3 | tekenen contract constructiebureau | milestone | 0w | 2003-01-17 | 2003-01-17 | 110 | 105d |  |
| 112 | 5.3.4 | selecteren installatie-bureau |  | 2w | 2002-12-30 | 2003-01-10 | 102 | 155d | 0d |
| 113 | 5.3.5 | ontwerp-contract opstellen |  | 2w | 2003-01-13 | 2003-01-24 | 112 | 155d | 0d |
| 114 | 5.3.6 | tekenen contract installatie-bureau | milestone | 0w | 2003-01-24 | 2003-01-24 | 113 | 155d |  |
| 115 | 5.4 | **ontwerpen: bouwkundig** |  | 70d | 2003-01-27 | 2003-05-02 |  | 15d |  |
| 116 | 5.4.1 | concept indelingsplannen |  | 6w | 2003-01-27 | 2003-03-07 | 107 | 15d | 0d |
| 117 | 5.4.2 | overleg indeling met gebruikers |  | 6w | 2003-02-24 | 2003-04-04 | 116SS+4w | 25d | 0d |
| 118 | 5.4.3 | document indelingsplannen maken |  | 6w | 2003-03-24 | 2003-05-02 | 117SS+4w | 25d | 0d |
| 119 | 5.4.4 | concept gevel aanzichten |  | 3w | 2003-01-27 | 2003-02-14 | 116SS | 70d | 0d |
| 120 | 5.4.5 | overleg over gevels |  | 1w | 2003-02-17 | 2003-02-21 | 119 | 70d | 0d |
| 121 | 5.4.6 | document gevelaanzichten maken |  | 2w | 2003-02-24 | 2003-03-07 | 120 | 70d |  |
| 122 | 5.5 | **ontwerpen: draagconstructie** |  | 30d | 2003-02-24 | 2003-04-04 |  | 50d |  |
| 123 | 5.5.1 | concept ontwerp draagconstructie |  | 3w | 2003-02-24 | 2003-03-14 | 116SS+4w | 50d | 0d |
| 124 | 5.5.2 | overleg over draagconstructie |  | 1w | 2003-03-17 | 2003-03-21 | 123 | 50d | 0d |
| 125 | 5.5.3 | document draagconstructie maken |  | 2w | 2003-03-24 | 2003-04-04 | 124 | 50d |  |
| 126 | 5.6 | **ontwerpen: installatie** |  | 30d | 2003-02-24 | 2003-04-04 |  | 15d |  |
| 127 | 5.6.1 | concept ontwerp installatie |  | 3w | 2003-02-24 | 2003-03-14 | 116SS+4w | 15d | 0d |
| 128 | 5.6.2 | overleg over installaties |  | 1w | 2003-03-17 | 2003-03-21 | 127 | 15d | 0d |
| 129 | 5.6.3 | document ontwerp installaties |  | 2w | 2003-03-24 | 2003-04-04 | 128 | 15d | 0d |
| 130 | 5.7 | **begroten** |  | 20d | 2003-04-07 | 2003-05-02 |  | 15d |  |
| 131 | 5.7.1 | elementenbegroting maken |  | 2w | 2003-04-07 | 2003-04-18 | 129 | 15d | 0d |
| 132 | 5.7.2 | overleg over elementen begroting |  | 1w | 2003-04-21 | 2003-04-25 | 131 | 15d | 0d |
| 133 | 5.7.3 | document elementen-begroting |  | 1w | 2003-04-28 | 2003-05-02 | 132 | 15d | 0d |

| ID | WBS | Task | Type | Duration | Start | Finish | Predecessors | Total slack | Free slack |
| --- | --- | --- | --- | --- | --- | --- | --- | --- | --- |
| 134 | 5.8 | **beoordelen** |  | 30d | 2003-04-07 | 2003-05-16 |  | 20d |  |
| 135 | 5.8.1 | toets VO aan functioneel programma |  | 1w | 2003-04-07 | 2003-04-11 | 118FF-3w | 45d |  |
| 136 | 5.8.2 | toets VO aan ruimtelijk programma |  | 1w | 2003-05-05 | 2003-05-09 | 118 | 25d |  |
| 137 | 5.8.3 | toets VO aan technisch programma |  | 1w | 2003-04-07 | 2003-04-11 | 129 | 45d |  |
| 138 | 5.8.4 | toets VO aan financieel programma |  | 1w | 2003-05-05 | 2003-05-09 | 133 | 15d | 0d |
| 139 | 5.8.5 | afwijkingsrapport maken |  | 1w | 2003-05-12 | 2003-05-16 | 138 | 15d | 0d |
| 140 | 5.9 | **besluiten** |  | 5d | 2003-05-19 | 2003-05-23 |  | 15d |  |
| 141 | 5.9.1 | besluitvorming voorbereiden |  | 1w | 2003-05-19 | 2003-05-23 | 139 | 15d | 0d |
| 142 | 5.9.2 | voorlopig ontwerp goedgekeurd | milestone | 0w | 2003-05-23 | 2003-05-23 | 141 | 15d |  |
| 144 | 6 | **DEFINITIEF ONTWERP** |  | 110d | 2002-12-30 | 2003-05-30 |  | 10d |  |
| 145 | 6.1 | opdracht voor definitief ontwerp | milestone | 0w | 2002-12-30 | 2002-12-30 |  | 10d | 0d |
| 146 | 6.2 | **organiseren** |  | 25d | 2002-12-30 | 2003-01-31 |  | 10d |  |
| 147 | 6.2.1 | plan van aanpak uitwerken |  | 1w | 2002-12-30 | 2003-01-03 | 145 | 10d | 0d |
| 148 | 6.2.2 | overleg over plan van aanpak |  | 1w | 2003-01-06 | 2003-01-10 | 147 | 10d | 0d |
| 149 | 6.2.3 | document plan van aanpak maken |  | 2w | 2003-01-13 | 2003-01-24 | 148 | 10d | 0d |
| 150 | 6.2.4 | projectteam bemannen |  | 1w | 2003-01-27 | 2003-01-31 | 149 | 95d |  |
| 151 | 6.3 | **programmeren** |  | 20d | 2002-12-30 | 2003-01-24 |  | 100d |  |
| 152 | 6.3.1 | actualiseren funct. basisprogram |  | 1w | 2002-12-30 | 2003-01-03 | 145 | 150d | 0d |
| 153 | 6.3.2 | actualiseren ruimtelijk basisprogram |  | 1w | 2003-01-06 | 2003-01-10 | 152 | 100d | 0d |
| 154 | 6.3.3 | actualiseren technisch basisprogram |  | 1w | 2003-01-13 | 2003-01-17 | 153 | 100d | 0d |
| 155 | 6.3.4 | actualiseren financieel basisprogram |  | 1w | 2003-01-20 | 2003-01-24 | 154 | 100d |  |
| 156 | 6.4 | **ontwerpen: bouwkundig** |  | 70d | 2003-01-27 | 2003-05-02 |  | 10d |  |
| 157 | 6.4.1 | plattegronden tekening uitwerken |  | 6w | 2003-01-27 | 2003-03-07 | 149 | 10d | 0d |
| 158 | 6.4.2 | overleg met gebruikers |  | 6w | 2003-02-24 | 2003-04-04 | 157SS+4w | 25d | 0d |
| 159 | 6.4.3 | document plattegronden maken |  | 6w | 2003-03-24 | 2003-05-02 | 158SS+4w | 25d | 0d |
| 160 | 6.4.4 | ontwerp gevels + daken uitwerken |  | 3w | 2003-02-24 | 2003-03-14 | 157SS+4w | 40d | 0d |
| 161 | 6.4.5 | overleg over gevels + daken |  | 2w | 2003-03-17 | 2003-03-28 | 160 | 40d | 0d |
| 162 | 6.4.6 | document ontwerp gevels + daken |  | 2w | 2003-03-31 | 2003-04-11 | 161 | 40d | 0d |

| ID | WBS | Task | Type | Duration | Start | Finish | Predecessors | Total slack | Free slack |
| --- | --- | --- | --- | --- | --- | --- | --- | --- | --- |
| 163 | 6.5 | **ontwerpen: draagconstructie** |  | 35d | 2003-02-24 | 2003-04-11 |  | 45d |  |
| 164 | 6.5.1 | draagconstructie verder uitwerken |  | 3w | 2003-02-24 | 2003-03-14 | 157SS+4w | 45d | 0d |
| 165 | 6.5.2 | overleg over draagconstructie |  | 2w | 2003-03-17 | 2003-03-28 | 164 | 45d | 0d |
| 166 | 6.5.3 | document ontwerp draagconstructie |  | 2w | 2003-03-31 | 2003-04-11 | 165 | 45d |  |
| 167 | 6.6 | **ontwerpen: installaties** |  | 30d | 2003-02-24 | 2003-04-04 |  | 10d |  |
| 168 | 6.6.1 | ontwerp installatie verder uitwerken |  | 3w | 2003-02-24 | 2003-03-14 | 157SS+4w | 10d | 0d |
| 169 | 6.6.2 | overleg over installaties |  | 1w | 2003-03-17 | 2003-03-21 | 168 | 10d | 0d |
| 170 | 6.6.3 | document ontwerp installaties maken |  | 2w | 2003-03-24 | 2003-04-04 | 169 | 10d | 0d |
| 171 | 6.7 | **begroten** |  | 20d | 2003-04-07 | 2003-05-02 |  | 10d |  |
| 172 | 6.7.1 | elementenmateriaal begroting concept |  | 2w | 2003-04-07 | 2003-04-18 | 170 | 10d | 0d |
| 173 | 6.7.2 | overleg over begroting |  | 1w | 2003-04-21 | 2003-04-25 | 172 | 10d | 0d |
| 174 | 6.7.3 | document elementen-begroting maken |  | 1w | 2003-04-28 | 2003-05-02 | 173 | 10d | 0d |
| 175 | 6.8 | **beoordelen** |  | 30d | 2003-04-07 | 2003-05-16 |  | 20d |  |
| 176 | 6.8.1 | toets DO aan functioneel basisprogram |  | 1w | 2003-04-14 | 2003-04-18 | 162 | 40d |  |
| 177 | 6.8.2 | toets DO aan ruimtelijk basisprogram |  | 1w | 2003-05-05 | 2003-05-09 | 159 | 25d |  |
| 178 | 6.8.3 | toets DO aan technisch basisprogram |  | 1w | 2003-04-07 | 2003-04-11 | 170 | 45d |  |
| 179 | 6.8.4 | toets DO aan financieel basisprogram |  | 1w | 2003-05-05 | 2003-05-09 | 174 | 10d | 0d |
| 180 | 6.8.5 | afwijkingsrapport maken |  | 1w | 2003-05-12 | 2003-05-16 | 179 | 10d | 0d |
| 181 | 6.9 | **besluiten** |  | 10d | 2003-05-19 | 2003-05-30 |  | 10d |  |
| 182 | 6.9.1 | besluitvorming voorbereiden |  | 2w | 2003-05-19 | 2003-05-30 | 180 | 10d | 0d |
| 183 | 6.9.2 | goedkeuring definitief ontwerp | milestone | 0w | 2003-05-30 | 2003-05-30 | 182 | 10d |  |
| 185 | 7 | **BESTEK & TEKENING** |  | 110d | 2002-12-30 | 2003-05-30 |  | 10d |  |
| 186 | 7.1 | opdracht start bestek & tekening | milestone | 0w | 2002-12-30 | 2002-12-30 |  | 15d | 0d |
| 187 | 7.2 | **organiseren** |  | 30d | 2002-12-30 | 2003-02-07 |  | 10d |  |
| 188 | 7.2.1 | plan van aanpak concept uitwerken |  | 2w | 2002-12-30 | 2003-01-10 | 186 | 15d | 0d |
| 189 | 7.2.2 | overleg over plan van aanpak |  | 1w | 2003-01-13 | 2003-01-17 | 188 | 10d | 0d |
| 190 | 7.2.3 | document plan van aanpak |  | 2w | 2003-01-20 | 2003-01-31 | 189 | 10d | 0d |
| 191 | 7.2.4 | project-team bemannen |  | 1w | 2003-02-03 | 2003-02-07 | 190 | 10d | 0d |

| ID | WBS | Task | Duration | Start | Finish | Predecessors | Total slack | Free slack |
| --- | --- | --- | --- | --- | --- | --- | --- | --- |
| 192 | 7.3 | **ontwerpen: bouwkundig bestek** | 50d | 2003-02-10 | 2003-04-18 |  | 10d |  |
| 193 | 7.3.1 | plattegrond tekeningen maken | 6w | 2003-02-10 | 2003-03-21 | 191 | 10d | 0d |
| 194 | 7.3.2 | gevels en daken tekeningen maken | 4w | 2003-03-10 | 2003-04-04 | 193SS+4w | 50d |  |
| 195 | 7.3.3 | doorsnedes+detail tekeningen maken | 4w | 2003-03-10 | 2003-04-04 | 193SS+4w | 50d |  |
| 196 | 7.3.4 | bouwkundig bestek schrijven | 4w | 2003-03-10 | 2003-04-04 | 193SS+4w | 50d |  |
| 197 | 7.3.5 | controleren bouwkundig bestek&tek | 2w | 2003-03-24 | 2003-04-04 | 193 | 10d | 0d |
| 198 | 7.3.6 | document bouwkundig bestek&tek | 2w | 2003-04-07 | 2003-04-18 | 197 | 10d | 0d |
| 199 | 7.4 | **ontwerpen: constructie bestek** | 50d | 2003-03-10 | 2003-05-16 |  | 20d |  |
| 200 | 7.4.1 | constructie plattegronden tekenen | 3w | 2003-03-10 | 2003-03-28 | 193SS+4w | 20d | 0d |
| 201 | 7.4.2 | constructie doorsneden+details maken | 2w | 2003-03-31 | 2003-04-11 | 200 | 45d |  |
| 202 | 7.4.3 | constructie bestek schrijven | 3w | 2003-03-31 | 2003-04-18 | 200SS+3w | 20d | 0d |
| 203 | 7.4.4 | controleren constructie bestek&tek | 2w | 2003-04-21 | 2003-05-02 | 202 | 20d | 0d |
| 204 | 7.4.5 | document constructie bestek&tek | 2w | 2003-05-05 | 2003-05-16 | 203 | 20d |  |
| 205 | 7.5 | **ontwerpen: werktuigk. bestek** | 40d | 2003-03-10 | 2003-05-02 |  | 30d |  |
| 206 | 7.5.1 | werktuigkundig bestektek maken | 3w | 2003-03-10 | 2003-03-28 | 193SS+4w | 30d | 0d |
| 207 | 7.5.2 | werktuigkundig bestek schrijven | 3w | 2003-03-24 | 2003-04-11 | 206SS+2w | 30d | 0d |
| 208 | 7.5.3 | controleren werktuigk. bestek&tek | 1w | 2003-04-14 | 2003-04-18 | 207 | 30d | 0d |
| 209 | 7.5.4 | document werktuigk. bestek&tek | 2w | 2003-04-21 | 2003-05-02 | 208 | 30d |  |
| 210 | 7.6 | **ontwerpen: electra bestek** | 45d | 2003-03-10 | 2003-05-09 |  | 25d |  |
| 211 | 7.6.1 | electra bestektek maken | 3w | 2003-03-10 | 2003-03-28 | 193SS+4w | 25d | 0d |
| 212 | 7.6.2 | electra bestek schrijven | 3w | 2003-03-31 | 2003-04-18 | 211SS+3w | 25d | 0d |
| 213 | 7.6.3 | controleren electra. bestek&tek | 1w | 2003-04-21 | 2003-04-25 | 212 | 25d | 0d |
| 214 | 7.6.4 | document electra. bestek&tek | 2w | 2003-04-28 | 2003-05-09 | 213 | 25d |  |
| 215 | 7.7 | **beoordelen** | 20d | 2003-04-21 | 2003-05-16 |  | 10d |  |
| 216 | 7.7.1 | toets bestek aan funct. program | 1w | 2003-04-21 | 2003-04-25 | 198 | 10d | 0d |
| 217 | 7.7.2 | toets bestek aan ruimtelijk program | 1w | 2003-04-28 | 2003-05-02 | 216 | 30d |  |
| 218 | 7.7.3 | toets bestek aan techn. program | 1w | 2003-04-28 | 2003-05-02 | 216 | 10d | 0d |
| 219 | 7.7.4 | toets bestek aan financieel program | 1w | 2003-05-05 | 2003-05-09 | 218 | 10d | 0d |
| 220 | 7.7.5 | afwijkingsrapport maken | 1w | 2003-05-12 | 2003-05-16 | 219 | 10d | 0d |

| ID | WBS | Task | Type | Duration | Start | Finish | Predecessors | Total slack | Free slack |
| --- | --- | --- | --- | --- | --- | --- | --- | --- | --- |
| 221 | 7.8 | **besluiten** |  | 10d | 2003-05-19 | 2003-05-30 |  | 10d |  |
| 222 | 7.8.1 | besluitvorming voorbereiden |  | 2w | 2003-05-19 | 2003-05-30 | 220 | 10d | 0d |
| 223 | 7.8.2 | goedkeuring bestek&tekening | milestone | 0w | 2003-05-30 | 2003-05-30 | 222 | 10d |  |
| 225 | 8 | **PRIJSVORMING** |  | 120d | 2002-12-30 | 2003-06-13 |  | 0d |  |
| 226 | 8.1 | opdracht voor aanbesteding | milestone | 0w | 2002-12-30 | 2002-12-30 |  | 0d |  |
| 227 | 8.2 | **organiseren: plan van aanpak** |  | 20d | 2002-12-30 | 2003-01-24 |  | 100d |  |
| 228 | 8.2.1 | plan van aanpak opstellen |  | 1w | 2002-12-30 | 2003-01-03 | 226 | 100d | 0d |
| 229 | 8.2.2 | overleg over plan van aanpak |  | 1w | 2003-01-06 | 2003-01-10 | 228 | 100d | 0d |
| 230 | 8.2.3 | document plan van aanpak |  | 1w | 2003-01-13 | 2003-01-17 | 229 | 100d | 0d |
| 231 | 8.2.4 | project-team bemannen |  | 1w | 2003-01-20 | 2003-01-24 | 230 | 100d |  |
| 232 | 8.3 | **organiseren: uitnodiging aanbest.** |  | 50d | 2002-12-30 | 2003-03-07 |  | 0d |  |
| 233 | 8.3.1 | selectie criteria formuleren |  | 1w | 2002-12-30 | 2003-01-03 | 226 | 0d |  |
| 234 | 8.3.2 | gunnings criteria formuleren |  | 1w | 2002-12-30 | 2003-01-03 | 233SS | 0d |  |
| 235 | 8.3.3 | bekendmaking aanbesteding |  | 1w | 2003-01-06 | 2003-01-10 | 234 | 0d |  |
| 236 | 8.3.4 | aanmeldingstermijn |  | 4w | 2003-01-13 | 2003-02-07 | 235 | 0d |  |
| 237 | 8.3.5 | beoordelen op selectie-criteria |  | 1w | 2003-02-10 | 2003-02-14 | 236 | 0d |  |
| 238 | 8.3.6 | mededeling teveel en 5 loten |  | 1w | 2003-02-17 | 2003-02-21 | 237 | 0d |  |
| 239 | 8.3.7 | bestekstukken copieren |  | 1w | 2003-02-24 | 2003-02-28 | 238 | 0d |  |
| 240 | 8.3.8 | uitnodiging met bestek-documenten |  | 1w | 2003-03-03 | 2003-03-07 | 239 | 0d |  |
| 241 | 8.4 | **begroten: prijsvorming** |  | 30d | 2003-03-10 | 2003-04-18 |  | 0d |  |
| 242 | 8.4.1 | inschrijfbegroting maken |  | 6w | 2003-03-10 | 2003-04-18 | 240 | 0d |  |
| 243 | 8.4.2 | nadere inlichtingen verstrekken |  | 1w | 2003-04-07 | 2003-04-11 | 242SS+4w | 40d | 0d |
| 244 | 8.4.3 | nota van inlichting verzenden |  | 1w | 2003-04-14 | 2003-04-18 | 243 | 40d |  |
| 245 | 8.5 | **begroten: aanbesteden** |  | 10d | 2003-04-18 | 2003-05-02 |  | 0d |  |
| 246 | 8.5.1 | aanbesteding houden | milestone | 0w | 2003-04-18 | 2003-04-18 | 242 | 0d |  |
| 247 | 8.5.2 | aanbieding laagste prijs kiezen |  | 1w | 2003-04-21 | 2003-04-25 | 246 | 0d |  |
| 248 | 8.5.3 | begroting laagste inschrijver |  | 1w | 2003-04-28 | 2003-05-02 | 247 | 0d |  |

| ID | WBS | Task | Type | Duration | Start | Finish | Predecessors | Total slack | Free slack |
| --- | --- | --- | --- | --- | --- | --- | --- | --- | --- |
| 249 | 8.6 | **beoordelen:** |  | 15d | 2003-05-05 | 2003-05-23 |  | 0d |  |
| 250 | 8.6.1 | toets inschrijving aan bouwbudget |  | 1w | 2003-05-05 | 2003-05-09 | 248 | 0d |  |
| 251 | 8.6.2 | prijsoverleg met laagste inschrijver |  | 1w | 2003-05-12 | 2003-05-16 | 250 | 0d |  |
| 252 | 8.6.3 | afwijkingsrapport maken |  | 1w | 2003-05-19 | 2003-05-23 | 251 | 0d |  |
| 253 | 8.7 | **besluiten** |  | 15d | 2003-05-26 | 2003-06-13 | 249 | 0d |  |
| 254 | 8.7.1 | aannemingsovereenkomst opstellen |  | 1w | 2003-05-26 | 2003-05-30 | 252 | 0d |  |
| 255 | 8.7.2 | overleg met laagste inschrijver |  | 2w | 2003-06-02 | 2003-06-13 | 254 | 0d |  |
| 256 | 8.7.3 | aannemingsovereenkomst tekenen | milestone | 0w | 2003-06-13 | 2003-06-13 | 255 | 0d |  |
| 258 | 9 | **WERKVOORBEREIDING** |  | 45d | 2002-12-30 | 2003-02-28 |  | 95d |  |
| 259 | 9.1 | bouwopdracht+ start werkvoorbereiding | milestone | 0w | 2002-12-30 | 2002-12-30 |  | 130d | 0d |
| 260 | 9.2 | **organiseren** |  | 45d | 2002-12-30 | 2003-02-28 |  | 95d |  |
| 261 | 9.2.1 | productieschema ruwbouw maken |  | 1w | 2002-12-30 | 2003-01-03 | 259 | 130d | 0d |
| 262 | 9.2.2 | procedure contract grondwerk |  | 4w | 2002-12-30 | 2003-01-24 | 259 | 155d |  |
| 263 | 9.2.3 | procedure contract bemaling |  | 4w | 2002-12-30 | 2003-01-24 | 259 | 155d |  |
| 264 | 9.2.4 | procedure contract heiwerk |  | 4w | 2002-12-30 | 2003-01-24 | 259 | 155d |  |
| 265 | 9.2.5 | procedure levering heipalen |  | 6w | 2002-12-30 | 2003-02-07 |  | 145d |  |
| 266 | 9.2.6 | procedure overige onderaannemers |  | 8w | 2003-01-06 | 2003-02-28 | 261 | 130d |  |
| 267 | 9.2.7 | procedure overige leveringen |  | 8w | 2003-01-06 | 2003-02-28 | 261 | 130d |  |
| 268 | 9.3 | **werktekeningen** |  | 20d | 2003-01-06 | 2003-01-31 |  | 95d |  |
| 269 | 9.3.1 | werktekening bouwplaats-inrichting |  | 4w | 2003-01-06 | 2003-01-31 | 261 | 150d |  |
| 270 | 9.3.2 | werktekening palenplan |  | 4w | 2003-01-06 | 2003-01-31 | 261 | 150d |  |
| 271 | 9.3.3 | werktekening betonfundatie |  | 4w | 2003-01-06 | 2003-01-31 | 261 | 150d |  |
| 272 | 9.3.4 | werktekening begane grondvloer |  | 4w | 2003-01-06 | 2003-01-31 | 261 | 150d |  |
| 274 | 10 | **UITVOERING PROJECT** |  | 75d | 2002-12-30 | 2003-04-11 |  | 45d |  |
| 275 | 10.1 | start uitvoering op de bouwplaats | milestone | 0w | 2002-12-30 | 2002-12-30 |  | 80d | 0d |
| 276 | 10.2 | intervaltijd aanloopfase |  | 3w | 2002-12-30 | 2003-01-17 | 275 | 80d | 0d |
| 277 | 10.3 | intervaltijd onderbouwfase |  | 3w | 2003-01-20 | 2003-02-07 | 276 | 80d | 0d |
| 278 | 10.4 | intervaltijd bovenbouwfase |  | 2w | 2003-02-10 | 2003-02-21 | 277 | 80d |  |
| 279 | 10.5 | productietijd bovenbouw |  | 15w | 2002-12-30 | 2003-04-11 |  | 45d |  |
| 280 | 10.6 | intervaltijd gevel/dakfase |  | 4w | 2002-12-30 | 2003-01-24 |  | 65d | 0d |
| 281 | 10.7 | intervaltijd afbouwfase |  | 7w | 2003-01-27 | 2003-03-14 | 280 | 65d |  |
| 282 | 10.8 | productietijd afbouw |  | 15w | 2002-12-30 | 2003-04-11 |  | 45d |  |

| ID | WBS | Task | Type | Duration | Start | Finish | Predecessors | Total slack | Free slack |
| --- | --- | --- | --- | --- | --- | --- | --- | --- | --- |
| 284 | 11 | **OPLEVERING GEBOUW** |  | 40d | 2002-12-30 | 2003-02-21 |  | 80d |  |
| 285 | 11.1 | vooropname en gebreken registreren |  | 2w | 2002-12-30 | 2003-01-10 |  | 80d | 0d |
| 286 | 11.2 | gebreken vooraf herstellen |  | 2w | 2003-01-13 | 2003-01-24 | 285 | 80d | 0d |
| 287 | 11.3 | formele oplevering | milestone | 0w | 2003-01-24 | 2003-01-24 | 286 | 80d | 0d |
| 288 | 11.4 | gebreken herstellen |  | 4w | 2003-01-27 | 2003-02-21 | 287 | 80d |  |
| 289 | 11.5 | inrichten door opdrachtgever |  | 2w | 2003-01-27 | 2003-02-07 | 287SS | 90d | 0d |
| 290 | 11.6 | overhuizen naar nieuwe huisvesting | milestone | 0w | 2003-02-07 | 2003-02-07 | 289 | 90d |  |
